# 237 AIDA-ph1-ppl-0002v1 AIDA electronics

Schedule from MS Project, 2010-10-01 to 2011-01-17.
CCLRC Daresbury Laboratory

## Calendars

- Standard: Mon-Fri 08:00-12:00, 13:00-17:00; Sat-Sun off.

## Schedule

| ID | WBS | Task | Duration | Start | Finish | Predecessors | Total slack | Free slack | Constraint |
| --- | --- | --- | --- | --- | --- | --- | --- | --- | --- |
| 2 | 1 | **AIDA Electronics Manufacture** | 77d | 2010-10-01 | 2011-01-17 |  | 0d |  |  |
| 3 | 1.1 | **Crate** | 66d | 2010-10-01 | 2010-12-31 |  | 11d |  |  |
| 4 | 1.1.1 | Manufacture prototype crate | 3mo | 2010-10-01 | 2010-12-31 |  | 6d |  | start no earlier than 2010-10-01 |
| 5 | 1.1.2 | Order Material for all crates | 2w | 2010-10-26 | 2010-11-08 |  | 40d | 0d |  |
| 6 | 1.1.3 | Order Material for crate support structuer | 1w | 2010-11-09 | 2010-11-15 | 5 | 40d |  |  |
| 7 | 1.2 | **Modules** | 60d | 2010-10-26 | 2011-01-17 |  | 0d |  |  |
| 8 | 1.2.1 | Design heatsink | 2w | 2010-10-26 | 2010-11-08 |  | 0d |  |  |
| 9 | 1.2.2 | Manufacture FEE board mechanics | 6w | 2010-11-09 | 2010-12-20 | 8 | 15d |  |  |
| 10 | 1.2.3 | Design FEE board mechanics | 2w | 2010-11-09 | 2010-11-22 | 8 | 0d |  |  |
| 11 | 1.2.4 | Manufacture heatsink | 8w | 2010-11-23 | 2011-01-17 | 10 | 0d |  |  |
